# San Fillipo Schedule 11 19 2008

Schedule from MS Project, 2008-09-24 to 2009-03-17, A marks actual dates.
M.E. Construction, Inc.

## Calendars

- Standard: Mon-Fri 08:00-12:00, 13:00-17:00; Sat-Sun off. Exceptions (off unless hours are given): 2008-11-27 to 2008-11-28 (Holiday), 2008-12-24 to 2008-12-26 (Holiday).

## Resources

| Resource |
| --- |
| City of Palm bay |
| R. A. Connor |
| CEG |
| BLS & C |
| Petroleum Technitions |
| Atlantic Testing |
| John Schopke |
| Certified Plumbing |
| Division 16 Electrical |
| MEC / All Good |
| Atlantic Glass Systems |
| Tailored foam |
| Advanced Roofing Technology |
| Doug Gulick |
| Chuck Shell Plastering |
| D & H Magic Air |
| HD Construction Services |
| Commercial Refrigeration |
| Acousti |
| MEC All Good |
| Cabinets By Booth |
| Richards Paint |
| MEC |
| LSP |
| Division 16 |
| r |
| Pam's Parking Marking |
| East Coast Fence |
| Federal Rent a Fence |
| FPL |
| Richard's Paint |
| Space Coast Steel |
| Space Coast Steel / John Schopke |
| Universal Structures |
| Jojn Schopke / Barnes |
| MEC / HD Supply |
| BL |
| City of Palm Bay. |
| Leed Insulation |
| Continental Cabinets |

## Schedule

| ID | Task | Type | Duration | Start | Finish | Predecessors | Complete | Remaining | Total slack | Free slack | Constraint | Resources | Work | Actual work |
| --- | --- | --- | --- | --- | --- | --- | --- | --- | --- | --- | --- | --- | --- | --- |
| 1 | Precon City of Palm Bay |  | 1d? | 2008-09-24 A | 2008-09-24 A |  | 100% |  |  |  |  | City of Palm Bay. | 8h | 8h |
| 2 | Shop Drawing Review Underground |  | 25d | 2008-09-29 | 2008-10-31 | 1 |  |  | 8d | 0d | start no earlier than 2008-09-29 | CEG | 200h |  |
| 3 | Order Lift Station |  | 20d | 2008-11-03 | 2008-12-02 | 2 |  |  | 46d | 0d |  | R. A. Connor | 160h |  |
| 4 | survey property lines |  | 1d | 2008-10-09 A | 2008-10-09 A | 1FS+10d | 100% |  |  |  |  | BLS & C | 8h | 8h |
| 5 | sillt fence |  | 2d | 2008-10-10 A | 2008-10-13 | 4 | 65% | 0.7d | 6.5d | 0d |  | R. A. Connor | 16h | 10.4h |
| 6 | Construction Entrance rock entry |  | 1d | 2008-10-10 A | 2008-10-10 A | 4 | 100% |  |  |  |  | R. A. Connor | 8h | 8h |
| 7 | clear / grub |  | 10d | 2008-10-14 A | 2008-10-27 A | 6, 5 | 100% |  |  |  |  | R. A. Connor | 80h | 80h |
| 8 | Stake and Grade Fire Hydrant |  | 1d? | 2008-10-28 A | 2008-10-28 A | 7 | 100% |  |  |  |  | BLS & C | 8h | 8h |
| 9 | Install fire Hydrant |  | 5d | 2008-11-03 A | 2008-11-07 A | 2 | 100% |  |  |  |  | R. A. Connor | 40h | 40h |
| 10 | Permit | milestone | 1d? | 2008-10-24 A | 2008-10-24 A |  | 100% |  |  |  |  | City of Palm Bay. | 8h | 8h |
| 11 | Place and Finish Slab "C" Store |  | 2d | 2008-12-05 | 2008-12-08 | 29, 78, 80, 79 |  |  | 11d | 5d |  | John Schopke | 16h |  |
| 12 | Testing Fire Hydrant |  | 5d | 2008-11-10 A | 2008-11-14 A | 8, 9 | 100% |  |  |  |  | R. A. Connor | 40h | 40h |
| 13 | As-Built Fire Hydrant |  | 7d | 2008-11-17 | 2008-11-25 | 12 |  |  | 75d |  |  | BLS & C | 56h |  |
| 14 | Stake and Grade Pond and Building Pads Rough |  | 1d? | 2008-10-28 A | 2008-10-28 A | 7 | 100% |  |  |  |  | BLS & C | 8h | 8h |
| 15 | Excavate pond |  | 8d | 2008-11-06 A | 2008-11-17 | 7 | 10% | 7.2d | 0d |  |  | R. A. Connor | 64h | 6.4h |
| 16 | Install Overflow Weir |  | 5d | 2008-11-18 | 2008-11-24 | 15 |  |  | 65d | 0d |  | John Schopke | 40h |  |
| 17 | Sod Pond and Swales |  | 4d | 2008-12-01 | 2008-12-04 | 16, 18 |  |  | 65d | 0d |  | LSP | 32h |  |
| 18 | Install Rip Rap |  | 2d | 2008-11-25 | 2008-11-26 | 16 |  |  | 65d | 0d |  | MEC / HD Supply | 16h |  |
| 19 | Install Perimiter Fence |  | 5d | 2008-11-18 | 2008-11-24 | 15 |  |  | 76d |  |  | East Coast Fence | 40h |  |
| 20 | Install Security Fence |  | 2d | 2008-11-18 A | 2008-11-19 A | 15 | 100% |  |  |  |  | Federal Rent a Fence | 16h | 16h |
| 21 | Fill building pad |  | 6d | 2008-11-04 A | 2008-11-12 A | 15FS-6d | 100% |  |  |  |  | R. A. Connor | 48h | 48h |
| 22 | Stake and Grade Drainage Structures and Pipe |  | 1d? | 2008-11-18 | 2008-11-18 | 15 |  |  | 80d |  |  | BLS & C | 8h |  |
| 23 | compact test Building Pad |  | 1d? | 2008-11-19 A | 2008-11-19 A | 22 | 100% |  |  |  |  | Atlantic Testing | 8h | 8h |
| 24 | install water line |  | 3d | 2008-12-08 | 2008-12-10 | 31, 2, 30, 32 |  |  | 2d | 0d |  | R. A. Connor | 24h |  |
| 25 | As-Built Utilities |  | 7d | 2008-12-11 | 2008-12-19 | 31, 30, 24, 86 |  |  | 59d |  |  | BLS & C | 56h |  |
| 26 | Stake and Grade Parking Rough |  | 1d | 2008-12-11 | 2008-12-11 | 24, 30, 61, 31 |  |  | 2d | 0d |  | BLS & C | 8h |  |
| 27 | Cut and Compact West Entry |  | 2d | 2008-12-16 | 2008-12-17 | 26, 35FS-5d |  |  | 0d |  |  | R. A. Connor | 16h |  |
| 28 | Cut and Compact South Entry |  | 1d? | 2009-01-21 | 2009-01-21 | 158FS+15d |  |  | 0d |  |  | R. A. Connor | 8h |  |
| 29 | Plumbing Rough C Store |  | 3d | 2008-11-20 | 2008-11-24 | 76 |  |  | 8d | 0d | start no earlier than 2008-11-19 | Certified Plumbing | 24h |  |
| 30 | install sewer line |  | 3d | 2008-12-03 | 2008-12-05 | 31, 2, 32 |  |  | 2d | 0d |  | R. A. Connor | 24h |  |
| 31 | install Catch Basins & RCP |  | 8d | 2008-11-18 | 2008-12-01 | 15, 2 |  |  | 2d | 0d |  | R. A. Connor | 64h |  |
| 32 | Stake and Grade Water and Sewer |  | 1d? | 2008-12-02 | 2008-12-02 | 31 |  |  | 2d | 0d |  | BLS & C | 8h |  |
| 33 | Intall Lift Station |  | 5d | 2008-12-03 | 2008-12-09 | 31, 32, 3 |  |  | 53d | 52d |  | R. A. Connor | 40h |  |
| 34 | Stake and grade Buildings Tight |  | 1d | 2008-11-12 A | 2008-11-13 A | 21 | 100% |  |  |  |  | BLS & C | 8h | 8h |
| 35 | fill parking / grade |  | 8d | 2008-12-11 | 2008-12-22 | 65, 61 |  |  | 0d |  |  | R. A. Connor | 64h |  |
| 36 | Install Irrigation Well |  | 3d | 2008-12-12 | 2008-12-16 | 26 |  |  | 53d | 52d |  | LSP | 24h |  |
| 37 | Install Primary and Secondary Conduit |  | 4d | 2008-12-23 | 2008-12-31 | 35 |  |  | 54d |  |  | Division 16 Electrical | 32h |  |
| 38 | Irrigation Sleaves |  | 4d | 2008-12-23 | 2008-12-31 | 35 |  |  | 19d | 0d |  | LSP | 32h |  |
| 39 | Fine Stake and Grade Parking |  | 2d | 2009-01-01 | 2009-01-02 | 38, 35 |  |  | 19d |  |  | BLS & C | 16h |  |
| 40 | Form and Place Parking Concrete |  | 15d | 2009-01-30 | 2009-02-19 | 39, 158, 161, 163 |  |  | 0d |  |  | John Schopke | 120h |  |
| 41 | Install Flumes |  | 4d | 2009-02-20 | 2009-02-25 | 40 |  |  | 14d |  |  | John Schopke | 32h |  |
| 42 | Install Dumpster Gates |  | 1d? | 2009-02-20 | 2009-02-20 | 58, 40 |  |  | 17d |  |  | East Coast Fence | 8h |  |
| 43 | Curbs |  | 3d | 2009-02-20 | 2009-02-24 | 40 |  |  | 0d |  |  | John Schopke | 24h |  |
| 44 | Fine Grade Site Behind Curbs |  | 4d | 2009-02-25 | 2009-03-02 | 43 |  |  | 1d | 0d |  | R. A. Connor | 32h |  |
| 45 | Set Transformer |  | 1d? | 2009-03-03 | 2009-03-03 | 44 |  |  | 1d | 0d |  | FPL | 8h |  |
| 46 | Install Irrigation |  | 4d | 2009-03-04 | 2009-03-09 | 45, 38, 36 |  |  | 1d | 0d |  | LSP | 32h |  |
| 47 | Install Landscaping |  | 5d | 2009-03-10 | 2009-03-16 | 46, 45 |  |  | 1d |  |  | LSP | 40h |  |
| 48 | Install Fence Around Pond |  | 5d | 2008-12-05 | 2008-12-11 | 17 |  |  | 65d |  |  | East Coast Fence | 40h |  |
| 49 | Install Fence Around the Lift Station |  | 1d? | 2009-02-25 | 2009-02-25 | 43, 33 |  |  | 1d | 0d |  | East Coast Fence | 8h |  |
| 50 | Site Lighting |  | 2d | 2009-02-26 | 2009-02-27 | 49, 53 |  |  | 1d |  |  | Division 16 Electrical | 16h |  |
| 51 | Striping and Signage |  | 4d | 2009-02-25 | 2009-03-02 | 40, 43 |  |  | 0d |  |  | Pam's Parking Marking | 32h |  |
| 52 | As-built all Improvements |  | 10d | 2009-03-03 | 2009-03-16 | 43, 51, 50 |  |  | 0d |  |  | BLS & C | 80h |  |
| 53 | Site Lighting Conduit |  | 3d | 2008-12-23 | 2008-12-30 | 35 |  |  | 42d | 41d |  | Division 16 Electrical | 24h |  |
| 54 | Inspect Slab Prep Retail |  | 1d | 2008-12-12 | 2008-12-12 | 55 |  |  | 6d | 0d |  | City of Palm Bay. | 8h |  |
| 55 | Prep Slab Retail |  | 2d | 2008-12-10 | 2008-12-11 | 79, 82, 77 |  |  | 6d | 0d |  | John Schopke | 16h |  |
| 56 | Install Dumpster Pad |  | 4d | 2008-12-29 | 2009-01-01 | 30, 35, 107 |  |  | 50d | 0d |  | John Schopke | 32h |  |
| 57 | Driveway Inspection West Entry |  | 1d? | 2008-12-18 | 2008-12-18 | 27, 31 |  |  | 0d |  |  | City of Palm Bay. | 8h |  |
| 58 | Masonry Dumpster Pad |  | 2d | 2009-01-02 | 2009-01-05 | 56 |  |  | 50d | 33d |  | John Schopke | 16h |  |
| 59 | Form Parking Lot |  | 6d | 2008-12-23 | 2009-01-02 | 26, 35, 86, 87, 27 |  |  | 52d | 0d |  |  | 48h |  |
| 60 | Drive Way Inspection pre pour West Entry |  | 1d | 2008-12-23 | 2008-12-23 | 157 |  |  | 0d |  |  | City of Palm Bay. | 8h |  |
| 61 | canopy FND |  | 3d | 2008-12-08 | 2008-12-10 | 65 |  |  | 0d |  |  | Petroleum Technitions | 24h |  |
| 62 | Canopy Steel |  | 5d | 2008-12-11 | 2008-12-17 | 61 |  |  | 57d | 43d |  | Universal Structures | 40h |  |
| 63 | Set Pump Curbs |  | 3d | 2009-02-27 | 2009-03-03 | 61, 40FS+5d |  |  | 5d | 0d |  | Petroleum Technitions | 24h |  |
| 64 | Set Pumps |  | 5d | 2009-03-04 | 2009-03-10 | 63, 39 |  |  | 5d |  |  | Petroleum Technitions | 40h |  |
| 65 | install Fuel tanks |  | 20d | 2008-11-06 | 2008-12-05 | 15FS-8d |  |  | 0d |  |  | Petroleum Technitions | 160h |  |
| 66 | dig footing C Store |  | 2d | 2008-11-12 A | 2008-11-13 A | 23FS-1d, 34FS-1d | 100% |  |  |  |  | John Schopke | 16h | 16h |
| 67 | Test Compaction Foundations C Store |  | 1d? | 2008-11-14 A | 2008-11-14 A | 66 | 100% |  |  |  |  | Atlantic Testing | 8h | 8h |
| 68 | Dig Footing Retail |  | 2d | 2008-11-17 A | 2008-11-20 A | 66, 21, 23 | 100% |  |  |  | finish no earlier than 2008-11-18 | John Schopke | 16h | 16h |
| 69 | Test Compaction Retail Foundations |  | 1d? | 2008-11-21 | 2008-11-21 | 68 |  |  | 77d |  |  | Atlantic Testing | 8h |  |
| 70 | Anchor Bolts "C" Store |  | 1d? | 2008-11-24 A | 2008-11-24 A | 68 | 100% |  |  |  |  | Space Coast Steel / John Schopke | 8h | 8h |

| ID | Task | Duration | Start | Finish | Predecessors | Complete | Total slack | Free slack | Constraint | Resources | Work | Actual work |
| --- | --- | --- | --- | --- | --- | --- | --- | --- | --- | --- | --- | --- |
| 71 | inspection Building Foundation C Store | 1d | 2008-11-25 A | 2008-11-25 A | 66, 70 | 100% |  |  |  | City of Palm Bay. | 8h | 8h |
| 72 | Inspect Building Foundation Retail | 1d? | 2008-11-26 | 2008-11-26 | 68, 71 |  | 6d | 0d |  | City of Palm Bay. | 8h |  |
| 73 | Place Foundations C Store | 1d | 2008-11-17 A | 2008-11-17 A | 71 | 100% |  |  |  | John Schopke | 8h | 8h |
| 74 | Place Foundations Retail | 1d | 2008-12-01 | 2008-12-01 | 72, 73 |  | 6d | 0d | start no earlier than 2008-11-21 | John Schopke | 8h |  |
| 75 | lay Stem wall Retail | 3d | 2008-12-02 | 2008-12-04 | 74, 76 |  | 6d | 3d |  | John Schopke | 24h |  |
| 76 | lay stem wall C Store | 2d | 2008-11-18 A | 2008-11-19 A | 73FS-1d | 100% |  |  |  | John Schopke | 16h | 16h |
| 77 | plumbing rough Retail | 2d | 2008-11-25 | 2008-11-26 | 29 |  | 10d | 0d |  | Certified Plumbing | 16h |  |
| 78 | Inspect Plumbing Rough C Store | 1d | 2008-11-25 | 2008-11-25 | 29 |  | 8d | 0d |  | City of Palm Bay. | 8h |  |
| 79 | Prep Slab C Store | 2d | 2008-12-02 | 2008-12-03 | 83 |  | 10d | 0d |  | John Schopke | 16h |  |
| 80 | Inspect Slab Prep C Store | 1d? | 2008-12-04 | 2008-12-04 | 79 |  | 11d | 0d |  | City of Palm Bay. | 8h |  |
| 81 | Electrical rough c store | 3d | 2008-11-26 | 2008-12-02 | 78 |  | 8d | 2d |  | Division 16 Electrical | 24h |  |
| 82 | Electrical Rough Retail | 3d | 2008-12-05 | 2008-12-09 | 81, 75, 77 |  | 6d | 0d |  | Division 16 Electrical | 24h |  |
| 83 | inspect Plumbing Rough Retail | 1d | 2008-12-01 | 2008-12-01 | 77 |  | 10d | 0d |  | City of Palm Bay. | 8h |  |
| 84 | set exterior door frames C Store | 1d | 2008-12-15 | 2008-12-15 | 54 |  | 6d | 0d |  | MEC / All Good | 8h |  |
| 85 | Set Exterior Door Frame Retail | 2d | 2008-12-17 | 2008-12-18 | 96, 84 |  | 14d | 2d |  | MEC / All Good | 16h |  |
| 86 | install grease trap | 1d | 2008-12-04 | 2008-12-04 | 77, 30FS-2d |  | 63d | 0d |  | Certified Plumbing | 8h |  |
| 87 | Inspect Grease Trap | 1d? | 2008-12-05 | 2008-12-05 | 86 |  | 63d | 11d |  | City of Palm Bay. | 8h |  |
| 88 | Masonry "C" Store | 5d | 2008-12-16 | 2008-12-22 | 11, 84 |  | 6d | 0d |  | John Schopke | 40h |  |
| 89 | Install Structural Steel | 2d | 2008-12-23 | 2008-12-29 | 88 |  | 6d | 0d |  | Space Coast Steel | 16h |  |
| 90 | Install Wood Blocking on Steel | 2d | 2008-12-30 | 2008-12-31 | 89, 88 |  | 6d | 0d |  | John Schopke | 16h |  |
| 91 | Pipe Bollards "C" Store | 1d | 2009-01-09 | 2009-01-09 | 88, 89, 104, 105 |  | 43d | 22d |  | Jojn Schopke / Barnes | 8h |  |
| 92 | Sidewalks "C" Store | 4d | 2009-02-11 | 2009-02-16 | 91, 151 |  | 21d |  |  | John Schopke | 32h |  |
| 93 | Siding Hardie Plank "C" Store | 5d | 2009-02-11 | 2009-02-17 | 105, 151 |  | 13d | 0d |  | John Schopke | 40h |  |
| 94 | Exterior Metal Framing Retail | 2d | 2009-01-29 | 2009-01-30 | 109 |  | 12d | 0d |  | Doug Gulick | 16h |  |
| 95 | Dense Glass Retail | 3d | 2009-02-02 | 2009-02-04 | 94 |  | 12d | 0d |  | Doug Gulick | 24h |  |
| 96 | Place and finish Slab Retail | 2d | 2008-12-15 | 2008-12-16 | 54, 55 |  | 14d | 0d |  | John Schopke | 16h |  |
| 97 | Masonry Retail Store | 8d | 2008-12-23 | 2009-01-06 | 74, 79, 54, 85, 88 |  | 12d | 0d |  | John Schopke | 64h |  |
| 98 | Sidewalks Retail Store | 4d | 2009-01-21 | 2009-01-26 | 97, 101, 108 |  | 36d |  |  | John Schopke | 32h |  |
| 99 | Measure and order Store Front C Store | 10d | 2009-01-01 | 2009-01-14 | 88, 90 |  | 8d | 0d |  | Atlantic Glass Systems | 80h |  |
| 100 | Measure Strore Front Retail | 1d? | 2009-01-15 | 2009-01-15 | 99, 97, 101 |  | 43d |  |  | Atlantic Glass Systems | 8h |  |
| 101 | Tie Beam Retail Building | 5d | 2009-01-07 | 2009-01-13 | 97 |  | 12d | 0d |  | John Schopke | 40h |  |
| 102 | core fill block "C" Store | 1d | 2008-12-23 | 2008-12-23 | 88 |  | 57d |  |  | Tailored foam | 8h |  |
| 103 | Core Fill Block Retail | 1d? | 2009-01-14 | 2009-01-14 | 97, 101 |  | 44d |  |  | Tailored foam | 8h |  |
| 104 | Set Trusses "C" Store | 3d | 2009-01-01 | 2009-01-05 | 88, 90 |  | 6d | 0d |  | John Schopke | 24h |  |
| 105 | decking "C" Store | 3d | 2009-01-06 | 2009-01-08 | 104 |  | 6d | 0d |  | John Schopke | 24h |  |
| 106 | ACM Panel "C" Store | 3d | 2009-02-16 | 2009-02-18 | 105, 148 |  | 19d |  |  | Universal Structures | 24h |  |
| 107 | Pipe Bollards Dumpster | 1d? | 2008-12-23 | 2008-12-23 | 30, 35 |  | 50d | 0d |  | Jojn Schopke / Barnes | 8h |  |
| 108 | Set Trusses Retail | 5d | 2009-01-14 | 2009-01-20 | 101, 104, 105 |  | 12d | 0d |  | John Schopke | 40h |  |
| 109 | Decking Retail | 6d | 2009-01-21 | 2009-01-28 | 108, 105 |  | 12d | 0d |  | John Schopke | 48h |  |
| 110 | Roof Dri In "C" Store | 2d | 2009-01-09 | 2009-01-12 | 105 |  | 6d | 0d |  | Advanced Roofing Technology | 16h |  |
| 111 | Install Insulation "C" Store | 1d | 2009-01-13 | 2009-01-13 | 110 |  | 6d | 0d |  | Leed Insulation | 8h |  |
| 112 | Drywall Lid C Store | 2d | 2009-01-14 | 2009-01-15 | 111, 110 |  | 6d | 0d |  | Doug Gulick | 16h |  |
| 113 | Roof Dri In Retail | 1d? | 2009-01-29 | 2009-01-29 | 109 |  | 22d | 3d |  | Advanced Roofing Technology | 8h |  |
| 114 | interior metal framing "C" Store | 3d | 2009-01-16 | 2009-01-20 | 105, 110, 112 |  | 6d | 0d |  | Doug Gulick | 24h |  |
| 115 | Framing Inspection C Store | 1d | 2009-02-05 | 2009-02-05 | 114, 120, 123, 124 |  | 6d | 0d |  | City of Palm Bay. | 8h |  |
| 116 | Measure & Manufacture Cabinets | 10d | 2009-02-06 | 2009-02-19 | 115 |  | 18d |  |  | Cabinets By Booth | 80h |  |
| 117 | Framing Inspection Retail | 1d | 2009-02-03 | 2009-02-03 | 108, 121, 123 |  | 30d |  |  | City of Palm Bay. | 8h |  |
| 118 | Install store front "C" Store | 2d | 2009-01-29 | 2009-01-30 | 104, 99FS+10d |  | 8d | 0d |  | Atlantic Glass Systems | 16h |  |
| 119 | store front Retail | 2d | 2009-02-02 | 2009-02-03 | 118 |  | 30d |  |  | Atlantic Glass Systems | 16h |  |
| 120 | plumbing top out C Store | 2d | 2009-01-21 | 2009-01-22 | 114 |  | 6d | 0d |  | Certified Plumbing | 16h |  |
| 121 | Plumbing Top Out Retail | 2d | 2009-01-23 | 2009-01-26 | 120 |  | 6d | 0d |  | Certified Plumbing | 16h |  |
| 122 | electrical in wall rough C Store | 4d | 2009-01-27 | 2009-01-30 | 114, 121 |  | 6d | 0d |  | Division 16 Electrical | 32h |  |
| 123 | Electrical Wall Rough Retail | 1d | 2009-02-02 | 2009-02-02 | 122 |  | 6d | 0d |  | Division 16 Electrical | 8h |  |
| 124 | a/c duct work C Store | 2d | 2009-02-03 | 2009-02-04 | 123 |  | 6d | 0d |  | D & H Magic Air | 16h |  |
| 125 | Air Handlers "C Store | 2d | 2009-02-05 | 2009-02-06 | 122, 114, 124 |  | 24d | 16d |  | D & H Magic Air | 16h |  |
| 126 | drywall "C" Store | 8d | 2009-02-06 | 2009-02-17 | 120, 127, 115 |  | 6d | 0d |  | Doug Gulick | 64h |  |
| 127 | cooler installed | 2d | 2009-01-19 | 2009-01-20 | 173, 114FS-2d |  | 18d | 12d |  | Commercial Refrigeration | 16h |  |
| 128 | Install Cooler Doors | 1d? | 2009-02-25 | 2009-02-25 | 127, 126, 168, 140 |  | 11d | 0d |  | Commercial Refrigeration | 8h |  |
| 129 | Install Cooler shelving | 2d | 2009-02-26 | 2009-02-27 | 128 |  | 11d | 2d |  | Commercial Refrigeration | 16h |  |
| 130 | Cooler Start up | 1d? | 2009-03-04 | 2009-03-04 | 129, 45 |  | 9d |  |  | Commercial Refrigeration | 8h |  |
| 131 | paint interior "C" Store | 3d | 2009-02-24 | 2009-02-26 | 132 |  | 10d | 0d |  | HD Construction Services | 24h |  |
| 132 | Ceiling grid "C" Store | 2d | 2009-02-20 | 2009-02-23 | 168 |  | 8d | 0d |  | Acousti | 16h |  |
| 133 | drop in lights C Store | 3d | 2009-02-23 | 2009-02-25 | 132FS-1d, 122 |  | 8d | 2d |  | Division 16 Electrical | 24h |  |
| 134 | a/c drops "C" Store | 2d | 2009-02-24 | 2009-02-25 | 132, 124 |  | 8d | 2d |  | D & H Magic Air | 16h |  |
| 135 | Condenser Set Start up HVAC C Store | 3d | 2009-03-03 | 2009-03-05 | 125, 136, 137 |  | 8d |  |  | D & H Magic Air | 24h |  |
| 136 | Temporary Power | 1d? | 2008-10-27 | 2008-10-27 | 10 |  | 95d | 93d |  | Division 16 Electrical | 8h |  |
| 137 | above ceiling inspection | 1d | 2009-03-02 | 2009-03-02 | 133, 134, 132, 143 |  | 6d | 0d |  | City of Palm Bay. | 8h |  |
| 138 | Drop ceiling tile "C" Store | 2d | 2009-03-06 | 2009-03-09 | 137FS+3d |  | 6d |  |  | Acousti | 16h |  |
| 139 | Wall tile | 4d | 2009-02-17 | 2009-02-20 | 126FS-1d |  | 6d | 0d |  | Richard's Paint | 32h |  |
| 140 | floor tile | 4d | 2009-02-19 | 2009-02-24 | 139FS-2d, 126 |  | 6d | 0d |  | Richard's Paint | 32h |  |

| ID | Task | Duration | Start | Finish | Predecessors | Total slack | Free slack | Resources | Work |
| --- | --- | --- | --- | --- | --- | --- | --- | --- | --- |
| 141 | Install Cabinets | 2d | 2009-02-23 | 2009-02-24 | 140FS-2d | 6d | 0d | Continental Cabinets | 16h |
| 142 | Install VCT | 2d | 2009-02-20 | 2009-02-23 | 168 | 16d |  | Richard's Paint | 16h |
| 143 | plumbing trim out "C" Store | 5d | 2009-02-23 | 2009-02-27 | 140FS-2d, 141FS-2d | 6d | 0d | Certified Plumbing | 40h |
| 144 | Bath Accessories | 2d | 2009-03-02 | 2009-03-03 | 139, 143 | 8d | 2d | MEC / HD Supply | 16h |
| 145 | electrical trim C Store | 5d | 2009-02-20 | 2009-02-26 | 168 | 8d | 0d | Division 16 Electrical | 40h |
| 146 | Electrical Trim Retail | 3d | 2009-02-27 | 2009-03-03 | 145, 131 | 10d |  | Division 16 Electrical | 24h |
| 147 | Metal roofing on "C" Store | 8d | 2009-01-23 | 2009-02-03 | 110, 120 | 19d | 0d | Advanced Roofing Technology | 64h |
| 148 | Metal Roofing on Retail | 8d | 2009-02-04 | 2009-02-13 | 147, 113, 121 | 19d | 0d | Advanced Roofing Technology | 64h |
| 149 | dense glass "C" Store | 2d | 2009-01-06 | 2009-01-07 | 104, 80 | 25d | 17d | Doug Gulick | 16h |
| 150 | set doors/ hardware C Store | 4d | 2009-02-20 | 2009-02-25 | 168 | 14d |  | MEC / All Good | 32h |
| 151 | stucco "C" Store | 7d | 2009-02-02 | 2009-02-10 | 118, 149, 88 | 8d | 0d | Chuck Shell Plastering | 56h |
| 152 | stucco Retail Building | 7d | 2009-02-05 | 2009-02-13 | 95 | 12d | 0d | Chuck Shell Plastering | 56h |
| 153 | Driveway Inspection South Entry | 1d? | 2009-01-22 | 2009-01-22 | 28 | 0d |  | City of Palm Bay. | 8h |
| 154 | siding hardie plank Retail | 6d | 2009-02-16 | 2009-02-23 | 152 | 12d | 0d | John Schopke | 48h |
| 155 | trim out / columns Retail | 4d | 2009-02-24 | 2009-02-27 | 154 | 12d |  | John Schopke | 32h |
| 156 | Parking Inspection Prepour | 1d? | 2009-01-01 | 2009-01-01 | 59FS-2d | 53d |  | City of Palm Bay. | 8h |
| 157 | Place Valley Curb West Entry | 2d | 2008-12-19 | 2008-12-22 | 27, 57 | 0d |  | John Schopke | 16h |
| 158 | Place Concrete West Entry | 2d | 2008-12-29 | 2008-12-30 | 157, 60 | 0d |  | John Schopke | 16h |
| 159 | Sidewalk Inspection West Side | 1d? | 2008-12-23 | 2008-12-23 | 157 | 54d | 0d | City of Palm Bay. | 8h |
| 160 | Sidewalks West Property Line | 3d | 2008-12-29 | 2008-12-31 | 157, 159 | 54d |  | John Schopke | 24h |
| 161 | Place Valley Curb South Entry | 2d | 2009-01-23 | 2009-01-26 | 28, 153 | 0d |  | John Schopke | 16h |
| 162 | Driveway Inspction Prepour | 1d? | 2009-01-27 | 2009-01-27 | 161, 153 | 0d |  | City of Palm Bay. | 8h |
| 163 | Place Concrete South Entry | 2d | 2009-01-28 | 2009-01-29 | 162 | 0d |  | John Schopke | 16h |
| 164 | Place Sidewalks South Side | 3d | 2009-01-30 | 2009-02-03 | 163 | 30d |  | John Schopke | 24h |
| 165 | Trim Out Columns, brackets "C" Store | 3d | 2009-02-18 | 2009-02-20 | 93 | 13d | 5d | John Schopke | 24h |
| 166 | Exterior painting "C" Store | 4d | 2009-02-25 | 2009-03-02 | 93FS-1d, 151FS+10d, 165FS-3d | 8d | 0d | HD Construction Services | 32h |
| 167 | Exterior Painting Retail | 3d | 2009-03-03 | 2009-03-05 | 166 | 8d |  | HD Construction Services | 24h |
| 168 | Prime Walls "C" Store | 2d | 2009-02-18 | 2009-02-19 | 126 | 8d | 0d | HD Construction Services | 16h |
| 169 | power up equipment | 3d | 2009-03-03 | 2009-03-05 | 137, 133, 145 | 6d | 0d | Division 16 Electrical | 24h |
| 170 | final clean up | 1d? | 2009-03-02 | 2009-03-02 | 143 | 9d | 3d | MEC | 8h |
| 171 | C Store Final | 1d? | 2009-03-06 | 2009-03-06 | 170, 144, 143, 169 | 6d |  |  | 8h |
| 172 | site final | 1d | 2009-03-17 | 2009-03-17 | 52, 171 | 0d |  | City of Palm Bay. | 8h |
| 173 | Measure & Manufacture Cooler | 15d | 2008-12-23 | 2009-01-15 | 88 | 19d | 1d | Commercial Refrigeration | 120h |
| 174 | Sheet Canopy | 4d | 2009-02-20 | 2009-02-25 | 62, 40 | 14d |  | Universal Structures | 32h |
